# 03_SwissGroovesPlanung_Parallelisierung-AP_Bontekoe-Rohrer

Schedule from MS Project, 2014-04-01 to 2015-02-10.

## Calendars

- Standard: Mon-Fri 08:00-12:00, 13:00-17:00; Sat-Sun off.

## Resources

| Resource |
| --- |
| Blair Tony |
| Blocher Christoph |
| Berlusconi Silvio |
| Clay Cassius |
| Clinton Hillary |
| Lauda Niki |
| Obama Barak |
| Pelé |
| Putin Vladimir |
| Sarkozy Nicolas |
| Bush George |

## Schedule

| ID | WBS | Task | Type | Duration | Start | Finish | Predecessors | Total slack | Free slack | Constraint | Resources | Work | Profile |
| --- | --- | --- | --- | --- | --- | --- | --- | --- | --- | --- | --- | --- | --- |
| 1 | 1 | Projektstart | milestone, manual | 0d | 2014-04-01 | 2014-04-01 |  |  |  |  |  |  |  |
| 2 | 2 | **SwissGrooves** |  | 225d | 2014-04-01 | 2015-02-10 | 1 | 0d |  |  |  | 5672h |  |
| 3 | 2.1 | **R1 Applikationssoftware** |  | 160d | 2014-06-03 | 2015-01-13 |  | 0d |  |  |  | 2920h |  |
| 4 | 2.1.1 | **R1.1 PoC** |  | 35d | 2014-06-03 | 2014-07-21 | 25 | 0d |  |  |  | 864h |  |
| 5 | 2.1.1.1 | POC-Model |  | 15d | 2014-06-03 | 2014-06-23 |  | 20d |  | start no earlier than 2014-05-28 | Berlusconi Silvio; Blocher Christoph [80%]; Bush George [90%] | 324h | DB-Architekt, SW-Architekt |
| 6 | 2.1.1.2 | POC-System |  | 20d | 2014-06-24 | 2014-07-21 |  | 0d |  | start no earlier than 2014-06-24 | Berlusconi Silvio; Blocher Christoph [80%]; Bush George [90%] | 432h | DB-Architekt, SW-Architekt |
| 7 | 2.1.1.3 | POC-CD |  | 15d | 2014-06-03 | 2014-06-23 |  | 15d |  | start no earlier than 2014-05-13 | Obama Barak [90%] | 108h | Marketing |
| 8 | 2.1.2 | Meilenstein-3 | milestone, manual | 0d | 2014-07-22 | 2014-07-22 | 4 |  |  |  |  |  |  |
| 9 | 2.1.3 | **R1.2 AR1.0** |  | 80d | 2014-09-23 | 2015-01-13 |  | 0d |  |  |  | 2056h |  |
| 10 | 2.1.3.1 | **R1.2.1 Basic** |  | 30d | 2014-09-23 | 2014-11-03 | 30 | 0d |  |  |  | 608h |  |
| 11 | 2.1.3.1.1 | App-Design |  | 30d | 2014-09-23 | 2014-11-03 |  | 0d |  |  | Blocher Christoph [80%] | 192h | SW-Architekt |
| 12 | 2.1.3.1.2 | App-Spez |  | 25d | 2014-09-23 | 2014-10-27 |  | 5d |  |  | Sarkozy Nicolas | 200h | Requirement-Engineer |
| 13 | 2.1.3.1.3 | App-DB |  | 30d | 2014-09-23 | 2014-11-03 |  | 0d |  |  | Bush George [90%] | 216h | DB-Architekt |
| 14 | 2.1.3.2 | Meilenstein-5 | milestone, manual | 0d | 2014-11-04 | 2014-11-04 | 10 |  |  |  |  |  |  |
| 15 | 2.1.3.3 | **R1.2.2 Release** |  | 50d | 2014-11-04 | 2015-01-12 | 10, 30 | 0d |  |  |  | 1448h |  |
| 16 | 2.1.3.3.1 | App-Content |  | 25d | 2014-11-04 | 2014-12-08 |  | 25d |  |  | Blair Tony | 200h | Technischer Redaktor |
| 17 | 2.1.3.3.2 | App-Identity |  | 20d | 2014-11-04 | 2014-12-01 |  | 30d |  |  | Blocher Christoph [80%] | 128h | SW-Entwickler |
| 18 | 2.1.3.3.3 | App-Social |  | 30d | 2014-11-04 | 2014-12-15 |  | 20d |  |  | Berlusconi Silvio | 240h | SW-Entwickler |
| 19 | 2.1.3.3.4 | App-Cash |  | 45d | 2014-11-04 | 2015-01-12 |  | 0d |  |  | Lauda Niki | 360h | SW-Entwickler |
| 20 | 2.1.3.3.5 | App-Trace |  | 45d | 2014-11-04 | 2015-01-05 |  | 5d |  |  | Clay Cassius | 360h | SW-Entwickler |
| 21 | 2.1.3.3.6 | App-Feedback |  | 20d | 2014-11-04 | 2014-12-01 |  | 30d |  |  | Pelé | 160h | SW-Entwickler |
| 22 | 2.1.3.4 | Meilenstein-6 | milestone, manual | 0d | 2015-01-13 | 2015-01-13 | 15 |  |  |  |  |  |  |
| 23 | 2.2 | **R2 Applikationskonzept** |  | 200d | 2014-05-06 | 2015-02-09 | 1 | 0d |  |  |  | 1872h |  |
| 24 | 2.2.1 | **R2.1 AK** |  | 100d | 2014-05-06 | 2014-09-23 |  | 0d |  |  |  | 1540.8h |  |
| 25 | 2.2.1.1 | **R2.1.1 AK0.5** |  | 20d | 2014-05-06 | 2014-06-02 | 60, 64 | 15d | 0d |  |  | 446.4h |  |
| 26 | 2.2.1.1.1 | Prototyp-Model |  | 10d | 2014-05-06 | 2014-05-19 |  | 25d |  | start no earlier than 2014-05-05 | Berlusconi Silvio; Blocher Christoph [80%]; Bush George [90%] | 172.8h | DB-Architekt, SW-Architekt |
| 27 | 2.2.1.1.2 | Prototyp-System |  | 12d | 2014-05-16 | 2014-06-02 |  | 15d |  | start no earlier than 2014-05-16 | Blocher Christoph [80%]; Berlusconi Silvio; Bush George [90%] | 216h | System-Engineer, Network-Engineer |
| 28 | 2.2.1.1.3 | Prototyp-CD |  | 8d | 2014-05-06 | 2014-05-15 |  | 27d |  |  | Obama Barak [90%] | 57.6h | Marketing |
| 29 | 2.2.1.2 | Meilenstein-2 | milestone, manual | 0d | 2014-06-03 | 2014-06-03 | 25 |  |  |  |  |  |  |

Notes:
- 1: SwissGrooves
- 4: Proof of Concept
- 5: Prototyp: Kontext-Diagramm Informatiosnmodell Funktionsgliederung
- 6: System Design: Hardware / Software
- 7: Corporate Design / Benutzeroberfläche
- 8: PoC Fertig
- 9: Applikationsrelease 1.0
- 10: Basis-Release
- 11: Detailliertes Design Detaillierte Beschreibung der Benutzeroberfläche & Navigationsstruktur Usability Styleguide
- 12: Funktionale und nichtfunktionale Spezifikation Schnittstellenkonzept
- 13: Datenmodell
- 14: Basis-Release Fertig
- 15: Release
- 16: Content-Management inkl. Aktualität (Produkt-Fotos etc.)
- 17: Identitiy-Management / Kundenlogin (Kunden-IDs)
- 18: Social-Features
- 19: Rabatt Optionen Zahlungs-Dienstleistung Inkasso-Dienstleistung
- 20: Auslieferung und Tracking Optionen
- 21: Feedback und Beschwerdemanagement
- 22: Release Fertig
- 24: Applikationskonzept „SwissGrooves
- 25: Applikationskonzept „SwissGrooves für den Pilot/PoC
- 26: Prototyp: Kontext-Diagramm Informatiosnmodell Funktionsgliederung
- 27: System Design: Hardware / Software
- 28: Corporate Design / Benutzeroberfläche
- 29: PoC Applikationskonzept Fertig

| ID | WBS | Task | Type | Duration | Start | Finish | Predecessors | Total slack | Constraint | Resources | Work | Profile |
| --- | --- | --- | --- | --- | --- | --- | --- | --- | --- | --- | --- | --- |
| 30 | 2.2.1.3 | **R2.1.2 AK-Spez** |  | 45d | 2014-07-22 | 2014-09-22 |  | 0d |  |  | 1094.4h |  |
| 31 | 2.2.1.3.1 | **R2.1.2.1 Basic** |  | 20d | 2014-07-22 | 2014-08-18 | 4 | 0d |  |  | 312h |  |
| 32 | 2.2.1.3.1.1 | Concept-Design |  | 15d | 2014-07-22 | 2014-08-18 |  | 0d |  | Obama Barak [90%] | 108h | Marketing |
| 33 | 2.2.1.3.1.2 | Concept-Spez |  | 12d | 2014-07-22 | 2014-08-06 |  | 2d |  | Sarkozy Nicolas | 96h | Requirement-Engineer |
| 34 | 2.2.1.3.1.3 | Concept-DB |  | 15d | 2014-07-22 | 2014-08-11 |  | 5d |  | Bush George [90%] | 108h | DB-Architekt |
| 35 | 2.2.1.3.2 | **R2.1.2.2 Release** |  | 25d | 2014-08-19 | 2014-09-22 | 4, 31 | 0d |  |  | 782.4h |  |
| 36 | 2.2.1.3.2.1 | Concept-Content |  | 12d | 2014-08-19 | 2014-09-03 |  | 13d |  | Blair Tony | 96h | Technischer Redaktor |
| 37 | 2.2.1.3.2.2 | Concept-Identity |  | 12d | 2014-08-19 | 2014-09-03 |  | 13d |  | Obama Barak [90%] | 86.4h | SW-Entwickler |
| 38 | 2.2.1.3.2.3 | Concept-Social |  | 15d | 2014-09-01 | 2014-09-19 |  | 1d |  | Berlusconi Silvio | 120h | SW-Entwickler |
| 39 | 2.2.1.3.2.4 | Concept-Cash |  | 25d | 2014-08-19 | 2014-09-22 |  | 0d |  | Lauda Niki | 200h | SW-Entwickler |
| 40 | 2.2.1.3.2.5 | Concept-Trace |  | 25d | 2014-08-19 | 2014-09-22 |  | 0d |  | Clay Cassius | 200h | SW-Entwickler |
| 41 | 2.2.1.3.2.6 | Concept-Feedback |  | 10d | 2014-08-19 | 2014-09-08 |  | 10d |  | Pelé | 80h | SW-Entwickler |
| 42 | 2.2.1.4 | Meilenstein-4 | milestone, manual | 0d | 2014-09-23 | 2014-09-23 | 30 |  |  |  |  |  |
| 43 | 2.2.2 | **R2.2 TK** |  | 135d | 2014-07-22 | 2015-01-26 |  | 10d |  |  | 128h |  |
| 44 | 2.2.2.1 | **R2.2.1 TK-PoC** |  | 20d | 2014-07-22 | 2014-08-18 | 4 | 125d |  |  | 64h |  |
| 45 | 2.2.2.1.1 | Testkonzept |  | 10d | 2014-07-22 | 2014-08-18 |  | 125d |  | Clinton Hillary [80%] | 64h | Test-Engineer |
| 46 | 2.2.2.2 | **R2.2.2 TK-Complete** |  | 10d | 2015-01-13 | 2015-01-26 | 9 | 10d |  |  | 64h |  |
| 47 | 2.2.2.2.1 | TK-Complete |  | 10d | 2015-01-13 | 2015-01-26 |  | 10d |  | Clinton Hillary [80%] | 64h | Test-Engineer |
| 48 | 2.2.3 | **R2.3 BHB** |  | 20d | 2015-01-13 | 2015-02-09 | 9 | 0d |  |  | 160h |  |
| 49 | 2.2.3.1 | BHB-Doc |  | 5d | 2015-01-13 | 2015-01-19 |  | 15d |  | Sarkozy Nicolas | 40h | Technischer Redaktor |
| 50 | 2.2.3.2 | BHB-Wiki |  | 5d | 2015-01-20 | 2015-01-26 |  | 10d | start no earlier than 2015-01-20 | Berlusconi Silvio | 40h | Technischer Redaktor |
| 51 | 2.2.3.3 | BHB-Online |  | 10d | 2015-01-27 | 2015-02-09 |  | 0d | start no earlier than 2015-01-27 | Lauda Niki | 80h | Technischer Redaktor |
| 52 | 2.2.4 | **R2.4 OHB1.0** |  | 3d | 2015-01-13 | 2015-01-15 | 9 | 17d |  |  | 43.2h |  |
| 53 | 2.2.4.1 | OHB-Prozesse |  | 3d | 2015-01-13 | 2015-01-15 |  | 17d |  | Blocher Christoph [80%] | 19.2h | Technischer Redaktor |
| 54 | 2.2.4.2 | OHB-Recovery |  | 2d | 2015-01-13 | 2015-01-14 |  | 18d |  | Clay Cassius | 16h | Technischer Redaktor |
| 55 | 2.2.4.3 | OHB-Naming |  | 1d | 2015-01-13 | 2015-01-13 |  | 19d |  | Pelé | 8h | Technischer Redaktor |

Notes:
- 30: Applikationskonzept für „SwissGrooves Vers. 1.0 (definitive Fassung)
- 31: Basis-Concept
- 32: Detailliertes Design Detaillierte Beschreibung der Benutzeroberfläche & Navigationsstruktur Usability Styleguide
- 33: Funktionale und nichtfunktionale Spezifikation Schnittstellenkonzept
- 34: Datenmodell
- 35: Release
- 36: Content-Management inkl. Aktualität (Produkt-Fotos etc.)
- 37: Identitiy-Management / Kundenlogin (Kunden-IDs)
- 38: Social-Features
- 39: Rabatt Optionen Zahlungs-Dienstleistung Inkasso-Dienstleistung
- 40: Auslieferung und Tracking Optionen
- 41: Feedback und Beschwerdemanagement
- 42: Applikationskonzept Fertig
- 43: Testkonzept
- 44: Testkonzept Vers. 0.5
- 45: Testfälle definieren
- 46: Testkonzept Vers 1.0 für Webshop Vers. 1.0
- 47: Vollständiges Testkonzept erstellen
- 48: Webshop Benutzer-Handbuch
- 49: Benutzerhandbuch in Dokumentenform
- 50: Wiki mit Hinweisen zur Benutzung des Systems
- 51: Online-Hilfe, vom Webshop aus zu erreichen
- 52: Webshop Betriebs-Handbuch
- 53: Wichtigsten IT Prozesse dokumentieren
- 54: Restart / Recovery Prozeduren dokumentieren
- 55: Naming-Konzept definieren

| ID | WBS | Task | Type | Duration | Start | Finish | Predecessors | Total slack | Free slack | Constraint | Resources | Work | Profile |
| --- | --- | --- | --- | --- | --- | --- | --- | --- | --- | --- | --- | --- | --- |
| 56 | 2.3 | **R3 Business-Ergebnisse** |  | 27d | 2014-04-08 | 2014-05-14 | 1 | 5d |  |  |  | 328h |  |
| 57 | 2.3.1 | **R3.1 BC** |  | 5d | 2014-04-08 | 2014-04-14 |  | 33d | 0d |  |  | 36h |  |
| 58 | 2.3.1.1 | BC |  | 5d | 2014-04-08 | 2014-04-14 |  | 33d | 0d | start no earlier than 2014-04-08 | Obama Barak [90%] | 36h | Marketing |
| 59 | 2.3.2 | Meilenstein-1 | milestone, manual | 0d | 2014-04-15 | 2014-04-15 | 57 |  |  |  |  |  |  |
| 60 | 2.3.3 | **R3.2 BO** |  | 12d | 2014-04-15 | 2014-04-30 | 58 | 26d | 0d |  |  | 116h |  |
| 61 | 2.3.3.1 | BO-Webshop |  | 5d | 2014-04-24 | 2014-04-30 |  | 26d |  | start no earlier than 2014-04-24 | Putin Vladimir | 40h | Prozess-Designer |
| 62 | 2.3.3.2 | BO-Schema |  | 5d | 2014-04-15 | 2014-04-21 |  | 33d |  |  | Obama Barak [90%] | 36h | Marketing |
| 63 | 2.3.3.3 | BO-Strategie |  | 5d | 2014-04-15 | 2014-04-21 |  | 33d |  |  | Putin Vladimir | 40h | Prozess-Designer |
| 64 | 2.3.4 | **R3.3 RG** |  | 15d | 2014-04-15 | 2014-05-05 | 58 | 23d | 0d |  |  | 96h |  |
| 65 | 2.3.4.1 | Recht-Feature |  | 5d | 2014-04-15 | 2014-04-21 |  | 33d |  | start no earlier than 2014-04-07 | Clinton Hillary [80%] | 32h | Rechtlicher-Berater |
| 66 | 2.3.4.2 | Recht-Usab |  | 5d | 2014-04-22 | 2014-04-28 |  | 28d |  | start no earlier than 2014-04-22 | Clinton Hillary [80%] | 32h | Rechtlicher-Berater |
| 67 | 2.3.4.3 | Recht-AGB |  | 5d | 2014-04-29 | 2014-05-05 |  | 23d |  | start no earlier than 2014-04-29 | Clinton Hillary [80%] | 32h | Rechtlicher-Berater |
| 68 | 2.3.5 | **R3.4 NP** |  | 10d | 2014-05-01 | 2014-05-14 | 60 | 193d |  |  |  | 80h |  |
| 69 | 2.3.5.1 | Produkt-Digital |  | 5d | 2014-05-01 | 2014-05-07 |  | 198d |  | start no earlier than 2014-04-23 | Sarkozy Nicolas | 40h | Technischer Redaktor |
| 70 | 2.3.5.2 | Produkt-Hardware |  | 5d | 2014-05-08 | 2014-05-14 |  | 193d |  | start no earlier than 2014-05-08 | Sarkozy Nicolas | 40h | Technischer Redaktor |
| 71 | 2.4 | **R4 Rollout** |  | 20d | 2015-01-13 | 2015-02-09 | 1 | 0d |  |  |  | 320h |  |
| 72 | 2.4.1 | **R4.1 RO** |  | 10d | 2015-01-13 | 2015-01-26 | 9 | 5d | 0d |  |  | 80h |  |
| 73 | 2.4.1.1 | Konzept-Rollout |  | 10d | 2015-01-13 | 2015-01-26 |  | 5d |  |  | Blair Tony | 80h | Roll-Out-Engineer |
| 74 | 2.4.2 | **R4.2 MK** |  | 20d | 2015-01-13 | 2015-02-09 | 9 | 0d |  |  |  | 144h |  |
| 75 | 2.4.2.1 | Konzept-Marketing |  | 20d | 2015-01-13 | 2015-02-09 |  | 0d |  |  | Obama Barak [90%] | 144h | Marketing |
| 76 | 2.4.3 | **R4.3 SK** |  | 5d | 2015-01-27 | 2015-02-02 | 9 | 2d |  |  |  | 40h |  |
| 77 | 2.4.3.1 | Konzept-Schulungs |  | 5d | 2015-01-27 | 2015-02-02 |  | 2d | 0d | start no earlier than 2015-01-27 | Blair Tony | 40h | Roll-Out-Engineer |
| 78 | 2.4.4 | **R4.4 SCH** |  | 3d | 2015-02-03 | 2015-02-05 | 77 | 2d |  |  |  | 24h |  |
| 79 | 2.4.4.1 | Schulung |  | 3d | 2015-02-03 | 2015-02-05 |  | 2d |  | start no earlier than 2015-01-27 | Blair Tony | 24h | Roll-Out-Engineer |

Notes:
- 57: Business Case „SwissGrooves
- 58: Business Case (klassisch)
- 59: Business Case Fertig
- 60: Geschäftsprozesse & -Modell/Strategie „SwissGrooves
- 61: Geschäftsprozesse für den Betrieb des Webshops
- 62: Graphische Darstellung der Produkt-, Service- Informations- und Geldflüsse sowie deren Akteure
- 63: Strategie basierend auf Geschäftsidee, Marktanalyse, Konkurrenzanalyse, Zielgruppen und Erfolgsfaktoren
- 64: Zahlungssystem & rechtliche Grundlagen
- 65: Evaluierung und Beurteilung der zu verwendenden Zahlungsmechanismen
- 66: Kundenfreundlichkeit (Zahlungsmethoden), Sicherheit der Zahlungsmethoden
- 67: AGB mit Jurist verifizieren / anpassen
- 68: Neue Produkte
- 69: Musikstücke zum Herunterladen
- 70: Produkte der Unterhaltungselektronik
- 72: Konzept Rollout SwissGrooves
- 73: Konzept für das Rollout des Webshops inkl. aller relevanten Schrite
- 74: Marketingkonzept
- 75: Marketingkonzept beschreibt Einführungsmassnahmen und Werbung
- 76: Schulungskonzept SwissGrooves
- 77: Schulungskonzept ausarbeiten für Endkunden und interne Mitarbeiter
- 78: Schulungsdurchführung
- 79: Schulungsdurchfühung in Bern und Basel

| ID | WBS | Task | Type | Duration | Start | Finish | Predecessors | Total slack | Free slack | Constraint | Resources | Work | Profile |
| --- | --- | --- | --- | --- | --- | --- | --- | --- | --- | --- | --- | --- | --- |
| 80 | 2.4.5 | **R4.5 BP** |  | 5d | 2015-01-27 | 2015-02-02 | 72 | 5d |  |  |  | 32h |  |
| 81 | 2.4.5.1 | Webshop-Befüllung |  | 5d | 2015-01-27 | 2015-02-02 |  | 5d |  |  | Blocher Christoph [80%] | 32h | Technischer Redaktor |
| 82 | 2.5 | Meilenstein-7 | milestone, manual | 0d | 2015-02-10 | 2015-02-10 | 71 |  |  |  |  |  |  |
| 83 | 2.6 | **R5 PM-Ergebnisse** |  | 82d | 2014-04-01 | 2014-07-23 | 1 | 143d |  |  |  | 232h |  |
| 84 | 2.6.1 | **R5.1 PA** |  | 5d | 2014-04-01 | 2014-04-07 |  | 220d |  |  |  | 40h |  |
| 85 | 2.6.1.1 | Projektantrag |  | 5d | 2014-04-01 | 2014-04-07 |  | 220d |  | start no earlier than 2014-04-01 | Putin Vladimir | 40h | Projektleiter |
| 86 | 2.6.2 | **R5.2 PP** |  | 17d | 2014-04-22 | 2014-05-14 |  | 193d |  |  |  | 96h |  |
| 87 | 2.6.2.1 | **R5.2.1 PP0.4** |  | 2d | 2014-04-22 | 2014-04-23 |  | 198d |  |  |  | 16h |  |
| 88 | 2.6.2.1.1 | PP01 |  | 2d | 2014-04-22 | 2014-04-23 |  | 198d | 5d | start no earlier than 2014-04-22 | Putin Vladimir | 16h | Projektleiter |
| 89 | 2.6.2.2 | **R5.2.2 PP0.7** |  | 4d | 2014-05-01 | 2014-05-06 | 88 | 193d |  |  |  | 32h |  |
| 90 | 2.6.2.2.1 | PP07 |  | 4d | 2014-05-01 | 2014-05-06 |  | 193d | 0d | start no earlier than 2014-05-01 | Putin Vladimir | 32h | Projektleiter |
| 91 | 2.6.2.3 | **R5.2.3 PP1.0** |  | 6d | 2014-05-07 | 2014-05-14 | 90 | 193d |  |  |  | 48h |  |
| 92 | 2.6.2.3.1 | PP10 |  | 6d | 2014-05-07 | 2014-05-14 |  | 193d |  |  | Putin Vladimir | 48h | Projektleiter |
| 93 | 2.6.3 | **R5.3 RA** |  | 1d | 2014-07-22 | 2014-07-22 | 4 | 143d | 0d |  |  | 8h |  |
| 94 | 2.6.3.1 | RA |  | 1d | 2014-07-22 | 2014-07-22 |  | 143d |  |  | Putin Vladimir | 8h | Risk-Manager |
| 95 | 2.6.4 | **R5.4 KP** |  | 1d | 2014-07-23 | 2014-07-23 | 93 | 143d |  |  |  | 8h |  |
| 96 | 2.6.4.1 | KP |  | 1d | 2014-07-23 | 2014-07-23 |  | 143d |  |  | Putin Vladimir | 8h | Marketing |
| 97 | 2.6.5 | **R5.5 ST** |  | 10d | 2014-05-15 | 2014-05-28 |  | 183d |  |  |  | 80h |  |
| 98 | 2.6.5.1 | ST |  | 10d | 2014-05-15 | 2014-05-28 |  | 183d |  | start no earlier than 2014-05-15 | Putin Vladimir | 80h | Risk-Manager |

Notes:
- 80: Befüllung Webshop
- 81: Befüllung Webshop
- 82: Rollout komplet
- 84: Projektantrag
- 85: Projektantrag mit Ausgangszielen, Zielen, Scope und grober Projektplanung
- 86: Projektplan
- 87: Projektplan Version 0.4
- 88: Projektplan gemäss Ergebnisliste
- 89: Projektplan Version 0.7
- 90: Projektplan gemäss Ergebnisliste
- 91: Projektplan Version 1.0
- 92: Projektplan gemäss Ergebnisliste
- 93: Risikoanalyse
- 94: Risikoanalyse gemäss Ergebnisliste
- 95: Kommunikationsplan
- 96: Kommunikationsplan gemäss Ergebnisliste
- 97: Entscheidungsvorlage
- 98: Entscheidungsvorlage: Webshop mieten, Standardlösung kaufen oder OpenSource-Lösung anpassen?
